# Schedule

Schedule from MS Project, 2011-07-14 to 2011-10-21.
MBARI

## Calendars

- Standard: Mon-Fri 08:00-12:00, 13:00-17:00; Sat-Sun off.

## Schedule

| ID | WBS | Task | Duration | Start | Finish | Predecessors | Total slack | Free slack | Constraint |
| --- | --- | --- | --- | --- | --- | --- | --- | --- | --- |
| 1 | 1 | Power Take-Off System | 1d? | 2011-07-14 | 2011-07-14 |  | 71d |  |  |
| 2 | 2 | Hydraulic Concept Design Review | 6d? | 2011-07-14 | 2011-07-21 |  | 21d | 0d | finish no earlier than 2011-07-21 |
| 3 | 3 | Hydraulic System Design Work | 14d | 2011-07-22 | 2011-08-10 | 2 | 21d | 0d |  |
| 4 | 4 | Hydraulic System Fabrication | 31d? | 2011-08-11 | 2011-09-22 | 3 | 21d |  | start no earlier than 2011-08-11 |
| 5 | 5 | Hydraulic System Integration and Test | 6d? | 2011-09-22 | 2011-09-29 |  | 16d |  | finish no earlier than 2011-09-29 |
| 6 | 6 | Software Development | 32d? | 2011-07-14 | 2011-08-26 |  | 40d |  | finish no earlier than 2011-08-26 |
| 8 | 7 | Thruster System | 1d? | 2011-07-14 | 2011-07-14 |  | 71d |  |  |
| 9 | 8 | Thruster System Concept Design Review | 1d? | 2011-07-28 | 2011-07-28 |  | 20d | 0d | start no earlier than 2011-07-28 |
| 10 | 9 | Thruster System Design and Fabrication | 30d? | 2011-07-29 | 2011-09-08 | 9 | 20d | 0d | finish no earlier than 2011-09-08 |
| 11 | 10 | Thruster System Integration and Test | 11d? | 2011-09-09 | 2011-09-23 | 10 | 20d |  | start no earlier than 2011-09-09 |
| 13 | 11 | SubSurface Plate | 1d? | 2011-07-14 | 2011-07-14 |  | 71d |  |  |
| 14 | 12 | Software Development | 30d? | 2011-07-15 | 2011-08-25 |  | 26d | 0d | finish no earlier than 2011-08-25 |
| 15 | 13 | Mechanical Integration | 15d? | 2011-08-26 | 2011-09-15 | 14 | 26d |  | start no earlier than 2011-08-26 |
| 16 | 14 | Electrical Integration | 15d? | 2011-08-26 | 2011-09-15 |  | 26d |  | finish no earlier than 2011-09-15 |
| 18 | 15 | Buoy | 1d? | 2011-07-14 | 2011-07-14 |  | 71d |  |  |
| 19 | 16 | Software Development | 32d? | 2011-07-14 | 2011-08-26 |  | 40d |  | start no earlier than 2011-07-14 |
| 20 | 17 | Mechanical/Electrical Integration | 15d? | 2011-08-26 | 2011-09-15 |  | 26d |  | finish no earlier than 2011-09-15 |
| 22 | 18 | Software Testing | 10d? | 2011-09-19 | 2011-09-30 |  | 15d |  | finish no earlier than 2011-09-30 |
| 24 | 19 | Test Deployment #1 | 5d? | 2011-10-03 | 2011-10-07 |  | 10d |  | finish no earlier than 2011-10-07 |
| 25 | 20 | Test Deployment #2 | 5d? | 2011-10-17 | 2011-10-21 |  | 0d |  | finish no earlier than 2011-10-21 |
